# NCDOT PDN 2 Schedule copy

Schedule from MS Project, 2021-06-14 to 2021-07-15.

## Calendars

- Standard: Mon-Fri 08:00-12:00, 13:00-17:00; Sat-Sun off.

## Resources

| Resource |
| --- |
| Transportation Planning |
| Division CDE's |
| Feasibility Studies |
| ? |
| Funds Administration |
| STIP Unit |
| STIP Unit? |

## Schedule

| ID | WBS | Task | Type | Duration | Start | Finish | Predecessors | Total slack | Free slack | Constraint | Task Code | Discipline Code |
| --- | --- | --- | --- | --- | --- | --- | --- | --- | --- | --- | --- | --- |
| 1 | 1 | PDN Schedule Template - released 12.2021 |  | 1d? | 2021-06-14 | 2021-06-14 |  | 23d |  | start no earlier than 2021-06-14 |  |  |
| 2 | 2 | **Project Initiation (Stg 1)** |  | 5d? | 2021-06-14 | 2021-06-18 |  |  |  |  |  |  |
| 3 | 2.1 | Final STIP | milestone | 0d | 2021-06-14 | 2021-06-14 |  | 0d |  |  | MLSN | MLSN |
| 4 | 2.2 | **Initiate Environmental Analysis** |  | 3d? | 2021-06-15 | 2021-06-17 | 3 | 7d |  |  | 1EN1 | EN |
| 5 | 2.2.1 | Comments on Draft Scoping Report |  | 1d? | 2021-06-15 | 2021-06-15 | 53 | 7d | 0d |  | 1EN1 | EN |
| 6 | 2.2.2 | Complete ETRACS and Other Requests |  | 1d? | 2021-06-17 | 2021-06-17 | 54 | 7d | 0d |  | 1EN1 | EN |
| 7 | 2.2.3 | Landowner Letters |  | 1d? | 2021-06-17 | 2021-06-17 | 54 | 20d |  |  | 1EN1 | EN |
| 8 | 2.2.4 | Cultural Resources Programmatic Agreement Cultural Resources Screening Checklist for Section 106 |  | 1d? | 2021-06-17 | 2021-06-17 | 54 | 20d |  |  | 1EN1 | EN |
| 9 | 2.2.5 | Traffic Noise and Air Quality (TNAQ) Notification Scoping Report Recommendations |  | 1d? | 2021-06-17 | 2021-06-17 | 54 | 20d |  |  | 1EN1 | EN |
| 10 | 2.2.6 | Community Screening |  | 1d? | 2021-06-17 | 2021-06-17 | 54 | 20d |  |  | 1EN1 | EN |
| 11 | 2.3 | **Compile Aerial Photography & Mapping** |  | 6d? | 2021-06-14 | 2021-06-21 |  | 13d |  |  | 1PH2 | PH |
| 12 | 2.3.1 | Controlled Aerial Photography |  | 1d? | 2021-06-14 | 2021-06-14 |  | 13d | 0d |  | 1PH2 | PH |
| 13 | 2.3.2 | Large Scale Planimetric Mapping |  | 1d? | 2021-06-18 | 2021-06-18 | 39 | 14d |  |  | 1PH2 | PH |
| 14 | 2.3.3 | Elevation Data |  | 1d? | 2021-06-18 | 2021-06-18 | 39 | 14d |  |  | 1PH2 | PH |
| 15 | 2.3.4 | Digital Mosaic |  | 1d? | 2021-06-18 | 2021-06-18 | 39 | 13d | 0d |  | 1PH2 | PH |
| 16 | 2.3.5 | Airborne Survey Report |  | 1d? | 2021-06-21 | 2021-06-21 | 15 | 13d |  |  | 1PH2 | PH |
| 17 | 2.4 | **Initiate CR-RAVE, CLEAR and Value Assessment Activities** |  | 5d? | 2021-06-15 | 2021-06-21 |  | 7d |  |  | 1VM1 | VM |
| 18 | 2.4.1 | Constructability Review Checklist |  | 1d? | 2021-06-15 | 2021-06-15 | 53 | 7d | 0d |  | 1VM1 | VM |
| 19 | 2.4.2 | Risk Assessment Worksheet |  | 1d? | 2021-06-17 | 2021-06-17 | 54 | 13d | 0d |  | 1VM1 | VM |
| 20 | 2.4.3 | Risk Assessment Study |  | 1d? | 2021-06-18 | 2021-06-18 | 19 | 14d |  |  | 1VM1 | VM |
| 21 | 2.4.4 | Value Engineering (VE) Checklist |  | 1d? | 2021-06-18 | 2021-06-18 | 19 | 13d | 0d |  | 1VM1 | VM |
| 22 | 2.4.5 | Value Engineering (VE) Schedule |  | 1d? | 2021-06-21 | 2021-06-21 | 21 | 13d |  |  | 1VM1 | VM |
| 23 | 2.4.6 | CLEAR Database Search |  | 1d? | 2021-06-18 | 2021-06-18 | 19 | 14d |  |  | 1VM1 | VM |
| 24 | 2.4.7 | Value Assessment |  | 1d? | 2021-06-16 | 2021-06-16 | 55 | 20d | 0d |  | 1VM1 | VM |
| 25 | 2.4.8 | Value Assessment Worksheet |  | 1d? | 2021-06-17 | 2021-06-17 | 24 | 20d |  |  | 1VM1 | VM |

Notes:
- 1: Delete this line

| ID | WBS | Task | Duration | Start | Finish | Predecessors | Total slack | Free slack | Task Code | Discipline Code |
| --- | --- | --- | --- | --- | --- | --- | --- | --- | --- | --- |
| 26 | 2.5 | **Initiate Utility Investigations** | 3d? | 2021-06-15 | 2021-06-17 |  | 7d |  | 1UT2 | UT |
| 27 | 2.5.1 | Utility Risk Analysis and Inventory Report | 1d? | 2021-06-15 | 2021-06-15 | 53 | 7d | 0d | 1UT2 | UT |
| 28 | 2.5.2 | Utility Project Outline | 1d? | 2021-06-16 | 2021-06-16 | 27 | 20d | 0d | 1UT2 | UT |
| 29 | 2.5.3 | Utility Construction Requests | 1d? | 2021-06-17 | 2021-06-17 | 28 | 20d |  | 1UT2 | UT |
| 30 | 2.6 | **Initiate Public Engagement Tasks** | 5d? | 2021-06-14 | 2021-06-18 |  | 14d |  | 1PI1 | PI |
| 31 | 2.6.1 | RPO/MPO CTP/LRTP Outreach Documentation | 1d? | 2021-06-14 | 2021-06-14 | 3 | 23d |  | 1PI1 | PI |
| 32 | 2.6.2 | Public Involvement Plan (PIP) | 1d? | 2021-06-18 | 2021-06-18 | 6 | 14d |  | 1PI1 | PI |
| 33 | 2.7 | **Review Project Scoping** | 1d? | 2021-06-15 | 2021-06-15 |  | 7d |  | 1CG1 | CG |
| 34 | 2.7.1 | Project Scoping Report Review Comments | 1d? | 2021-06-15 | 2021-06-15 | 53 | 7d | 0d | 1CG1 | CG |
| 35 | 2.8 | **Provide Photogrammetric Control & Initiate Survey** | 3d? | 2021-06-15 | 2021-06-17 |  | 13d |  | 1LS1 | LS |
| 36 | 2.8.1 | Photogrammetric Control for Preliminary/Planning Mapping (NC Grid Datum) | 1d? | 2021-06-15 | 2021-06-15 | 12 | 13d | 0d | 1LS1 | LS |
| 37 | 2.8.2 | SUE Level D Mapping | 1d? | 2021-06-16 | 2021-06-16 | 36 | 21d |  | 1LS1 | LS |
| 38 | 2.8.3 | Final Mapping Limits Polygon | 1d? | 2021-06-16 | 2021-06-16 | 36 | 13d | 0d | 1LS1 | LS |
| 39 | 2.8.4 | Photogrammetric Control for Final Survey Mapping (Local Datum) | 1d? | 2021-06-17 | 2021-06-17 | 38 | 13d | 0d | 1LS1 | LS |
| 40 | 2.9 | **Complete Geotechnical & GeoEnvironmental Screening** | 4d? | 2021-06-14 | 2021-06-17 |  | 8d |  | 1GT1 | GT |
| 41 | 2.9.1 | Geotechnical Input on Express Design | 1d? | 2021-06-14 | 2021-06-14 | 3 | 23d |  | 1GT1 | GT |
| 42 | 2.9.2 | Geotechnical Report for Planning | 1d? | 2021-06-15 | 2021-06-15 | 53 | 7d | 0d | 1GT1 | GT |
| 43 | 2.9.3 | GeoEnvironmental Scoping Comments Report | 1d? | 2021-06-17 | 2021-06-17 | 54 | 20d |  | 1GT1 | GT |
| 44 | 2.10 | **Initiate Environmental Review** | 5d? | 2021-06-15 | 2021-06-21 |  | 6d |  | 1EP1 | EP |
| 45 | 2.10.1 | Merger Pre-Screening Review | 1d? | 2021-06-15 | 2021-06-15 | 53 | 6d | 0d | 1EP1 | EP |
| 46 | 2.10.2 | Merger Screening | 1d? | 2021-06-16 | 2021-06-16 | 45 | 6d | 0d | 1EP1 | EP |
| 47 | 2.10.3 | Merger Plan (if needed) | 1d? | 2021-06-17 | 2021-06-17 | 46 | 6d | 0d | 1EP1 | EP |
| 48 | 2.10.4 | Merger CP1 Meeting Packet | 1d? | 2021-06-18 | 2021-06-18 | 47 | 6d | 0d | 1EP1 | EP |
| 49 | 2.10.5 | CP Documentation | 1d? | 2021-06-21 | 2021-06-21 | 48 | 13d |  | 1EP1 | EP |

| ID | WBS | Task | Type | Duration | Start | Finish | Predecessors | Total slack | Free slack | Task Code | Discipline Code | SAP MLSN |
| --- | --- | --- | --- | --- | --- | --- | --- | --- | --- | --- | --- | --- |
| 50 | 2.11 | **Complete Traffic Forecast** |  | 1d? | 2021-06-14 | 2021-06-14 |  | 18d |  | 1TP1 | TP |  |
| 51 | 2.11.1 | Approved Traffic Forecast |  | 1d? | 2021-06-14 | 2021-06-14 | 3 | 23d |  | 1TP1 | TP |  |
| 52 | 2.12 | **Complete Project Scoping Report** |  | 3d? | 2021-06-14 | 2021-06-16 |  | 0d |  | 1FS3 | FS |  |
| 53 | 2.12.1 | Project Scoping Report Level-of -Detail Screening Form |  | 1d? | 2021-06-14 | 2021-06-14 | 3 | 0d |  | 1FS3 | FS |  |
| 54 | 2.12.2 | Project Scoping Report Package |  | 1d? | 2021-06-16 | 2021-06-16 | 5, 18, 27, 42, 34, 45 | 7d | 0d | 1FS3 | FS |  |
| 55 | 2.12.3 | Final project Initiation Packet |  | 1d? | 2021-06-15 | 2021-06-15 | 53 | 0d |  | 1FS3 | FS |  |
| 56 | 2.13 | Request Preliminary Engineering Funds |  | 1d? | 2021-06-16 | 2021-06-16 | 55 | 0d |  |  | PM |  |
| 57 | 2.14 | NTP | milestone | 0d | 2021-06-16 | 2021-06-16 | 55, 56 | 0d |  | MLSN | MLSN | M0965 |
| 58 | 3 | **Alignment Defined (Stg 2)** |  | 24d? | 2021-06-14 | 2021-07-15 | 3 | 0d |  |  |  |  |
| 59 | 3.1 | **Complete Final Surveys** |  | 2d? | 2021-06-17 | 2021-06-18 |  | 0d |  | 2LS1 | LS |  |
| 60 | 3.1.1 | Final Surveys |  | 1d? | 2021-06-17 | 2021-06-17 | 57 | 0d |  | 2LS1 | LS |  |
| 61 | 3.1.2 | Surveyed Wetlands |  | 1d? | 2021-06-18 | 2021-06-18 | 106 | 16d | 0d | 2LS1 | LS |  |
| 62 | 3.2 | **Complete SUE Level A & ROW Advance Acquisition Surveys** |  | 5d? | 2021-06-17 | 2021-06-23 |  | 16d |  | 2LS2 | LS |  |
| 63 | 3.2.1 | SUE Level A |  | 1d? | 2021-06-17 | 2021-06-17 | 57 | 20d |  | 2LS2 | LS |  |
| 64 | 3.2.2 | ROW Advanced Acquisition Surveys |  | 1d? | 2021-06-23 | 2021-06-23 | 68 | 16d |  | 2LS2 | LS |  |
| 65 | 3.3 | **Complete Design Recommendation Plan Set** |  | 11d? | 2021-06-18 | 2021-07-02 |  | 0d |  | 2RD1 | RD |  |
| 66 | 3.3.1 | Approved Design Criteria and Associated Typical Sections |  | 1d? | 2021-06-18 | 2021-06-18 | 60 | 0d |  | 2RD1 | RD |  |
| 67 | 3.3.2 | Design Public Meeting Maps |  | 1d? | 2021-06-21 | 2021-06-21 | 66 | 0d |  | 2RD1 | RD |  |
| 68 | 3.3.3 | Design Recommendation Plan Set |  | 1d? | 2021-06-22 | 2021-06-22 | 67 | 0d |  | 2RD1 | RD |  |
| 69 | 3.3.4 | Approved Design Exception |  | 1d? | 2021-06-24 | 2021-06-24 | 68, 79 | 0d |  | 2RD1 | RD |  |
| 70 | 3.3.5 | Initial Lighting Assessment |  | 1d? | 2021-06-25 | 2021-06-25 | 69 | 10d | 0d | 2RD1 | RD |  |
| 71 | 3.3.6 | Lighting Evaluation Report |  | 1d? | 2021-06-28 | 2021-06-28 | 70 | 10d | 0d | 2RD1 | RD |  |
| 72 | 3.3.7 | Agreement with Municipality for Lighting Ownership and Maintenance |  | 1d? | 2021-06-29 | 2021-06-29 | 71 | 10d | 1d | 2RD1 | RD |  |
| 73 | 3.3.8 | Location and Design Approval Support Document |  | 1d? | 2021-07-01 | 2021-07-01 | 72, 132 | 9d | 0d | 2RD1 | RD |  |
| 74 | 3.3.9 | Location and Design Approval Letter (LADA) |  | 1d? | 2021-07-02 | 2021-07-02 | 73 | 9d |  | 2RD1 | RD |  |

| ID | WBS | Task | Duration | Start | Finish | Predecessors | Total slack | Free slack | Task Code | Discipline Code |
| --- | --- | --- | --- | --- | --- | --- | --- | --- | --- | --- |
| 75 | 3.4 | **Develop Preliminary Hydraulic Recommendations** | 4d? | 2021-06-22 | 2021-06-25 |  | 1d |  | 2HY1 | HY |
| 76 | 3.4.1 | Hydraulic Planning Report (HPR) | 1d? | 2021-06-22 | 2021-06-22 | 67 | 4d | 3d | 2HY1 | HY |
| 77 | 3.4.2 | Preliminary Stormwater Management Plan (pSMP) | 1d? | 2021-06-25 | 2021-06-25 | 69 | 0d |  | 2HY1 | HY |
| 78 | 3.5 | **Complete Drainage Design for Field Inspection** | 7d? | 2021-06-23 | 2021-07-01 |  | 0d |  | 2HY2 | HY |
| 79 | 3.5.1 | Comments on Design Recommendation Plan Set(s) | 1d? | 2021-06-23 | 2021-06-23 | 68 | 0d |  | 2HY2 | HY |
| 80 | 3.5.2 | Hydraulics Pre-Design Meeting Documentation | 1d? | 2021-06-28 | 2021-06-28 | 79, 77 | 0d |  | 2HY2 | HY |
| 81 | 3.5.3 | Hydraulic Survey Reports for Major Structures | 1d? | 2021-06-29 | 2021-06-29 | 76, 80 | 0d |  | 2HY2 | HY |
| 82 | 3.5.4 | Drainage Plans for Merger CP4B Meeting and Minutes | 1d? | 2021-07-01 | 2021-07-01 | 81, 132 | 8d | 0d | 2HY2 | HY |
| 83 | 3.5.5 | Drainage Plans for Field Inspection | 1d? | 2021-06-29 | 2021-06-29 | 217 | 12d |  | 2HY2 | HY |
| 84 | 3.5.6 | Railroad Drainage Submittals | 1d? | 2021-06-24 | 2021-06-24 | 150 | 15d |  | 2HY2 | HY |
| 85 | 3.6 | **Prepare GeoEnvironmental Phase I Report** | 3d? | 2021-06-17 | 2021-06-21 |  | 18d |  | 2GT1 | GT |
| 86 | 3.6.1 | GeoEnvironmental Phase I Report | 1d? | 2021-06-17 | 2021-06-17 | 57 | 18d | 0d | 2GT1 | GT |
| 87 | 3.6.2 | GeoEnvironmental Phase I Spreadsheet | 1d? | 2021-06-18 | 2021-06-18 | 86 | 18d | 0d | 2GT1 | GT |
| 88 | 3.6.3 | GeoEnvironmental GIS Shape File | 1d? | 2021-06-21 | 2021-06-21 | 87 | 18d |  | 2GT1 | GT |
| 89 | 3.7 | **Conduct Subsurface Investigations & Provide Roadway Recommendations** | 4d? | 2021-06-23 | 2021-06-28 |  | 13d |  | 2GT2 | GT |
| 90 | 3.7.1 | Roadway Subsurface Investigation Inventory Report with graphics | 1d? | 2021-06-23 | 2021-06-23 | 68 | 13d | 0d | 2GT2 | GT |
| 91 | 3.7.2 | Right-of-Way recommendation Memo | 1d? | 2021-06-24 | 2021-06-24 | 90 | 13d | 0d | 2GT2 | GT |
| 92 | 3.7.3 | Roadway Recommendation Report possibly with graphics | 1d? | 2021-06-25 | 2021-06-25 | 91 | 13d | 0d | 2GT2 | GT |
| 93 | 3.7.4 | Special Provisions | 1d? | 2021-06-28 | 2021-06-28 | 92 | 13d |  | 2GT2 | GT |
| 94 | 3.8 | **Complete Pavement & Subgrade Investigation and Recommendations Report (PSIRR)** | 1d? | 2021-06-23 | 2021-06-23 |  | 15d |  | 2GT3 | GT |
| 95 | 3.8.1 | Pavement and Subgrade Investigation and Recommendations Report (PSIRR) | 1d? | 2021-06-23 | 2021-06-23 | 68 | 15d | 0d | 2GT3 | GT |
| 96 | 3.9 | **Complete Pavement Design** | 1d? | 2021-06-24 | 2021-06-24 |  | 15d |  | 2PD1 | PD |
| 97 | 3.9.1 | Final Pavement Design Memo | 1d? | 2021-06-24 | 2021-06-24 | 95 | 15d |  | 2PD1 | PD |
| 98 | 3.10 | **Initiate Structures Design** | 2d? | 2021-06-30 | 2021-07-01 |  | 0d |  | 2ST1 | ST |
| 99 | 3.10.1 | Preliminary/Final Scoping Sheet | 1d? | 2021-06-30 | 2021-06-30 | 68, 81 | 0d |  | 2ST1 | ST |
| 100 | 3.10.2 | Preliminary/Final Manday Estimate | 1d? | 2021-07-01 | 2021-07-01 | 99 | 0d |  | 2ST1 | ST |

| ID | WBS | Task | Duration | Start | Finish | Predecessors | Total slack | Free slack | Constraint | Task Code | Discipline Code |
| --- | --- | --- | --- | --- | --- | --- | --- | --- | --- | --- | --- |
| 101 | 3.11 | **Develop Preliminary General Drawings** | 3d? | 2021-07-02 | 2021-07-06 |  | 0d |  |  | 2ST2 | ST |
| 102 | 3.11.1 | Draft Preliminary General Drawings (PGDs) for Review | 1d? | 2021-07-02 | 2021-07-02 | 100 | 0d |  |  | 2ST2 | ST |
| 103 | 3.11.2 | Preliminary Header Elevations (if required) | 1d? | 2021-07-05 | 2021-07-05 | 102 | 0d |  |  | 2ST2 | ST |
| 104 | 3.11.3 | Final Preliminary General Drawings (PGDs) for Distribution | 1d? | 2021-07-06 | 2021-07-06 | 103 | 7d |  |  | 2ST2 | ST |
| 105 | 3.12 | **Advance Natural Environment Tasks** | 11d? | 2021-06-17 | 2021-07-01 |  | 10d |  |  | 2EN1 | EN |
| 106 | 3.12.1 | NRTR | 1d? | 2021-06-17 | 2021-06-17 | 57 | 16d | 0d |  | 2EN1 | EN |
| 107 | 3.12.2 | WEX File | 1d? | 2021-06-21 | 2021-06-21 | 61, 106 | 16d | 0d |  | 2EN1 | EN |
| 108 | 3.12.3 | Signed Jurisdictional Determination and Buffer Package | 1d? | 2021-06-22 | 2021-06-22 | 107 | 16d | 0d |  | 2EN1 | EN |
| 109 | 3.12.4 | WET File | 1d? | 2021-06-23 | 2021-06-23 | 108 | 16d |  |  | 2EN1 | EN |
| 110 | 3.12.5 | Comments on NEPA/SEPA Document | 1d? | 2021-07-01 | 2021-07-01 | 132 | 10d |  |  | 2EN1 | EN |
| 111 | 3.13 | **Advance Human Environment Tasks** | 14d? | 2021-06-14 | 2021-07-01 |  | 10d |  |  | 2EN2 | EN |
| 112 | 3.13.1 | Community Characteristics Report | 1d? | 2021-06-14 | 2021-06-14 |  | 23d |  |  | 2EN2 | EN |
| 113 | 3.13.2 | Indirect and Cumulative Effects Report | 1d? | 2021-06-18 | 2021-06-18 | 106 | 19d |  |  | 2EN2 | EN |
| 114 | 3.13.3 | Community Impacts Assessment | 1d? | 2021-06-25 | 2021-06-25 | 69 | 3d | 0d |  | 2EN2 | EN |
| 115 | 3.13.4 | Land Use Scenario Assessment | 1d? | 2021-06-28 | 2021-06-28 | 114 | 13d |  |  | 2EN2 | EN |
| 116 | 3.13.5 | Comments on NEPA/SEPA Document | 1d? | 2021-07-01 | 2021-07-01 | 132, 114 | 10d |  | start no earlier than 2021-06-28 | 2EN2 | EN |
| 117 | 3.13.6 | Complete Archaeological Surveys/Reports, if needed | 1d? | 2021-06-18 | 2021-06-18 | 6, 57 | 7d | 0d |  | 2EN2 | EN |
| 118 | 3.13.7 | Complete Archaeological Effects Determination, if needed | 1d? | 2021-06-21 | 2021-06-21 | 117, 66 | 7d | 4d |  | 2EN2 | EN |
| 119 | 3.13.8 | Complete Historic Architecture Surveys/Reports, if needed | 1d? | 2021-06-18 | 2021-06-18 | 6, 57 | 7d | 0d |  | 2EN2 | EN |
| 120 | 3.13.9 | Complete Historic Architecture Effects Determination, if needed | 1d? | 2021-06-21 | 2021-06-21 | 119, 66 | 7d | 4d |  | 2EN2 | EN |
| 121 | 3.13.10 | Cultural Resource MOA Development, if needed | 1d? | 2021-07-01 | 2021-07-01 | 118, 120, 132 | 10d |  |  | 2EN2 | EN |
| 122 | 3.13.11 | Comments on NEPA/SEPA Document | 1d? | 2021-07-01 | 2021-07-01 | 132 | 10d |  |  | 2EN2 | EN |
| 123 | 3.13.12 | Develop Traffic Noise Work Plan | 1d? | 2021-06-21 | 2021-06-21 | 66 | 18d |  |  | 2EN2 | EN |
| 124 | 3.13.13 | Develop Traffic Noise Report (TNR) | 1d? | 2021-06-23 | 2021-06-23 | 68 | 6d | 3d |  | 2EN2 | EN |
| 125 | 3.13.14 | Develop Air Quality Report | 1d? | 2021-06-21 | 2021-06-21 | 66 | 8d | 5d |  | 2EN2 | EN |
| 126 | 3.13.15 | Comments on NEPA/SEPA Document | 1d? | 2021-07-01 | 2021-07-01 | 132 | 10d |  |  | 2EN2 | EN |

| ID | WBS | Task | Duration | Start | Finish | Predecessors | Total slack | Free slack | Task Code | Discipline Code |
| --- | --- | --- | --- | --- | --- | --- | --- | --- | --- | --- |
| 127 | 3.14 | **Prepare Environmental Documentation** | 8d? | 2021-06-21 | 2021-06-30 |  | 6d |  | 2EP1 | EP |
| 128 | 3.14.1 | Merger Preparation Materials | 1d? | 2021-06-21 | 2021-06-21 | 48 | 6d | 0d | 2EP1 | EP |
| 129 | 3.14.2 | Comments on Merger Public Engagement Materials | 1d? | 2021-06-22 | 2021-06-22 | 128 | 6d | 3d | 2EP1 | EP |
| 130 | 3.14.3 | Merger CP Outcomes | 1d? | 2021-06-28 | 2021-06-28 | 129, 69, 76, 114, 118, 120, 175 | 3d | 0d | 2EP1 | EP |
| 131 | 3.14.4 | Comments on Environmental Documents | 1d? | 2021-06-29 | 2021-06-29 | 130, 124, 125 | 3d | 0d | 2EP1 | EP |
| 132 | 3.14.5 | Approved NEPA/SEPA Documentation | 1d? | 2021-06-30 | 2021-06-30 | 131 | 3d | 0d | 2EP1 | EP |
| 133 | 3.14.6 | Approved Section 4(f) Documentation | 1d? | 2021-06-30 | 2021-06-30 | 131 | 11d |  | 2EP1 | EP |
| 134 | 3.15 | **Complete Traffic Analysis** | 1d? | 2021-06-21 | 2021-06-21 |  | 10d |  | 2TM1 | TM |
| 135 | 3.15.1 | Traffic Operations Analysis Technical Memorandum | 1d? | 2021-06-21 | 2021-06-21 | 66 | 10d | 1d | 2TM1 | TM |
| 136 | 3.16 | **Initiate Transportation Management Plan** | 1d? | 2021-07-06 | 2021-07-06 |  | 0d |  | 2TM2 | TM |
| 137 | 3.16.1 | Temporary Traffic Control (TTC) Concept Plans | 1d? | 2021-07-06 | 2021-07-06 | 68, 77, 103, 135 | 0d |  | 2TM2 | TM |
| 138 | 3.17 | **Initiate Transportation Operations Plan (if a Significant Project)** | 7d? | 2021-07-07 | 2021-07-15 |  | 0d |  | 2TO1 | TO |
| 139 | 3.17.1 | Updated Operational Risk Assessment | 1d? | 2021-07-07 | 2021-07-07 | 137 | 0d |  | 2TO1 | TO |
| 140 | 3.17.2 | Traffic Operations Recommendations | 1d? | 2021-07-08 | 2021-07-08 | 139 | 0d |  | 2TO1 | TO |
| 141 | 3.17.3 | Initial Incident Management (Quick Clearance) Strategies Recommendations | 1d? | 2021-07-09 | 2021-07-09 | 140 | 0d |  | 2TO1 | TO |
| 142 | 3.17.4 | Draft Signal Timing Plans | 1d? | 2021-07-12 | 2021-07-12 | 171, 141 | 0d |  | 2TO1 | TO |
| 143 | 3.17.5 | Integrated Corridor Management Decision Matrix | 1d? | 2021-07-13 | 2021-07-13 | 142 | 0d |  | 2TO1 | TO |
| 144 | 3.17.6 | List of Smart Work zone Equipment | 1d? | 2021-07-14 | 2021-07-14 | 143 | 0d |  | 2TO1 | TO |
| 145 | 3.17.7 | Updated cost estimate | 1d? | 2021-07-15 | 2021-07-15 | 144 | 0d |  | 2TO1 | TO |
| 146 | 3.17.8 | Initial Stakeholder Meeting Minutes | 1d? | 2021-07-08 | 2021-07-08 | 139 | 5d |  | 2TO1 | TO |
| 147 | 3.18 | **Initiate Railroad Review** | 5d? | 2021-06-21 | 2021-06-25 |  | 14d |  | 2RR1 | RR |
| 148 | 3.18.1 | Railroad Design Line and Grade | 1d? | 2021-06-21 | 2021-06-21 | 66 | 18d |  | 2RR1 | RR |
| 149 | 3.18.2 | Railroad PE Agreement | 1d? | 2021-06-25 | 2021-06-25 | 151 | 14d |  | 2RR1 | RR |
| 150 | 3.18.3 | Roadway Plans for Rail Review | 1d? | 2021-06-23 | 2021-06-23 | 68 | 14d | 0d | 2RR1 | RR |
| 151 | 3.18.4 | Crossing Scope for Off-Site Detour | 1d? | 2021-06-24 | 2021-06-24 | 135, 150 | 14d | 0d | 2RR1 | RR |

| ID | WBS | Task | Duration | Start | Finish | Predecessors | Total slack | Free slack | Task Code | Discipline Code |
| --- | --- | --- | --- | --- | --- | --- | --- | --- | --- | --- |
| 152 | 3.19 | **Initiate Advance Acquisition ROW Tasks** | 2d? | 2021-06-23 | 2021-06-24 |  | 15d |  | 2RW1 | RW |
| 153 | 3.19.1 | Advance Acquisition Property Owner Contacts | 1d? | 2021-06-23 | 2021-06-23 | 68 | 15d | 0d | 2RW1 | RW |
| 154 | 3.19.2 | Advanced Acquisition ROW Authorization | 1d? | 2021-06-24 | 2021-06-24 | 153 | 15d |  | 2RW1 | RW |
| 155 | 3.20 | **Prepare ROW Cost Estimate** | 1d? | 2021-06-23 | 2021-06-23 |  | 15d |  | 2RW2 | RW |
| 156 | 3.20.1 | ROW Cost Estimate (PH 200) | 1d? | 2021-06-23 | 2021-06-23 | 68 | 15d | 0d | 2RW2 | RW |
| 157 | 3.21 | Request ROW Funds | 1d? | 2021-06-24 | 2021-06-24 | 156 | 15d |  |  | PM |
| 158 | 3.22 | **Initiate Utility Coordination** | 7d? | 2021-06-23 | 2021-07-01 |  | 7d |  | 2UT1 | UT |
| 159 | 3.22.1 | Utility Coordination Kickoff Meeting Minutes | 1d? | 2021-06-23 | 2021-06-23 | 68 | 7d | 0d | 2UT1 | UT |
| 160 | 3.22.2 | Routing Plan | 1d? | 2021-06-24 | 2021-06-24 | 159 | 7d | 0d | 2UT1 | UT |
| 161 | 3.22.3 | Relocation Schedule | 1d? | 2021-06-25 | 2021-06-25 | 160 | 7d | 0d | 2UT1 | UT |
| 162 | 3.22.4 | Preliminary Utility Construction Plans | 1d? | 2021-06-28 | 2021-06-28 | 161 | 7d | 0d | 2UT1 | UT |
| 163 | 3.22.5 | Subsurface Utility Engineering (SUE) Level A Request | 1d? | 2021-06-29 | 2021-06-29 | 162 | 7d | 0d | 2UT1 | UT |
| 164 | 3.22.6 | Geotechnical Investigation (Trenchless) Request | 1d? | 2021-06-30 | 2021-06-30 | 163 | 7d | 0d | 2UT1 | UT |
| 165 | 3.22.7 | Utility Easement Request and Utility Parcel List | 1d? | 2021-07-01 | 2021-07-01 | 164 | 7d | 0d | 2UT1 | UT |
| 166 | 3.23 | **Prepare Utility Relocation and Construction Estimates** | 2d? | 2021-07-02 | 2021-07-05 |  | 7d |  | 2UT2 | UT |
| 167 | 3.23.1 | Utility Relocation (PH 250) Estimate | 1d? | 2021-07-02 | 2021-07-02 | 165 | 7d | 0d | 2UT2 | UT |
| 168 | 3.23.2 | Utility Construction (PH 300) Estimate | 1d? | 2021-07-05 | 2021-07-05 | 167 | 7d | 0d | 2UT2 | UT |
| 169 | 3.24 | Request Utility Funds | 1d? | 2021-07-06 | 2021-07-06 | 168 | 7d |  |  | PM |
| 170 | 3.25 | **Initiate Signal and ITS Design** | 1d? | 2021-06-29 | 2021-06-29 |  | 8d |  | 2SG1 | SG |
| 171 | 3.25.1 | Signal Pole/Cabinet Location Diagrams | 1d? | 2021-06-29 | 2021-06-29 | 162 | 8d |  | 2SG1 | SG |
| 172 | 3.26 | **Complete Safety Analysis & Operational Review** | 11d? | 2021-06-23 | 2021-07-07 |  | 3d |  | 2TS1 | TS |
| 173 | 3.26.1 | Traffic Signal Recommendations | 1d? | 2021-06-23 | 2021-06-23 | 68 | 3d | 0d | 2TS1 | TS |
| 174 | 3.26.2 | Traffic Safety Alternatives Analysis Report | 1d? | 2021-06-24 | 2021-06-24 | 173 | 3d | 0d | 2TS1 | TS |
| 175 | 3.26.3 | Safety Data and Analysis for Environmental Document | 1d? | 2021-06-25 | 2021-06-25 | 174 | 3d | 0d | 2TS1 | TS |
| 176 | 3.26.4 | Roadway Plan Comment Memo | 1d? | 2021-06-28 | 2021-06-28 | 175 | 12d | 0d | 2TS1 | TS |
| 177 | 3.26.5 | Signing and Delineation Plan Comment Memo | 1d? | 2021-06-29 | 2021-06-29 | 176, 182 | 12d |  | 2TS1 | TS |
| 178 | 3.26.6 | Comments on the Transportation Management Plan (TMP) and temporary traffic control (TTC) plans | 1d? | 2021-07-07 | 2021-07-07 | 176, 137 | 6d |  | 2TS1 | TS |

| ID | WBS | Task | Duration | Start | Finish | Predecessors | Total slack | Free slack | Constraint | Task Code | Discipline Code |
| --- | --- | --- | --- | --- | --- | --- | --- | --- | --- | --- | --- |
| 179 | 3.27 | **Initiate Signing and Delineation Design** | 3d? | 2021-06-23 | 2021-06-25 |  | 13d |  |  | 2SD1 | SD |
| 180 | 3.27.1 | Preliminary Signing and Delineation Strip Map | 1d? | 2021-06-23 | 2021-06-23 | 68, 135 | 13d | 0d |  | 2SD1 | SD |
| 181 | 3.27.2 | Document Conflicts | 1d? | 2021-06-24 | 2021-06-24 | 180 | 13d | 0d |  | 2SD1 | SD |
| 182 | 3.27.3 | Plan Submittals | 1d? | 2021-06-25 | 2021-06-25 | 181 | 13d | 1d |  | 2SD1 | SD |
| 183 | 3.28 | **Verify Complete Streets** | 1d? | 2021-06-21 | 2021-06-21 |  | 18d |  |  | 2IM1 | IM |
| 184 | 3.28.1 | Integrated Mobility Division Concurrence Review Memo | 1d? | 2021-06-21 | 2021-06-21 | 66 | 18d |  |  | 2IM1 | IM |
| 185 | 3.29 | **Initiate Erosion and Sediment Control Plans** | 9d? | 2021-06-23 | 2021-07-05 |  | 8d |  |  | 2RE1 | RE |
| 186 | 3.29.1 | Water Quality Worksheet (Form ESC-1) | 1d? | 2021-06-23 | 2021-06-23 | 68 | 15d | 5d |  | 2RE1 | RE |
| 187 | 3.29.2 | Environmental Document Review (Form ESC-2) | 1d? | 2021-06-30 | 2021-06-30 | 131 | 10d | 0d |  | 2RE1 | RE |
| 188 | 3.29.3 | Pre-Design Meeting Minutes | 1d? | 2021-07-01 | 2021-07-01 | 186, 187 | 10d |  |  | 2RE1 | RE |
| 189 | 3.29.4 | E&SC Field Inspection Plans | 1d? | 2021-07-02 | 2021-07-02 | 82 | 8d | 0d |  | 2RE1 | RE |
| 190 | 3.29.5 | ROW/Easement Request File | 1d? | 2021-07-05 | 2021-07-05 | 156, 189 | 8d |  |  | 2RE1 | RE |
| 191 | 3.30 | **Continue Public Engagement** | 5d? | 2021-06-17 | 2021-06-23 |  | 16d |  |  | 2PI1 | PI |
| 192 | 3.30.1 | Public Involvement plan (PIP) | 1d? | 2021-06-17 | 2021-06-17 | 57 | 19d | 0d |  | 2PI1 | PI |
| 193 | 3.30.2 | Scoping Letter | 1d? | 2021-06-17 | 2021-06-17 | 57 | 16d | 0d |  | 2PI1 | PI |
| 194 | 3.30.3 | Mailing List | 1d? | 2021-06-18 | 2021-06-18 | 193 | 16d | 0d |  | 2PI1 | PI |
| 195 | 3.30.4 | Public Outreach Materials | 1d? | 2021-06-21 | 2021-06-21 | 194 | 16d | 0d |  | 2PI1 | PI |
| 196 | 3.30.5 | Newsletter/Postcard Approval | 1d? | 2021-06-22 | 2021-06-22 | 195 | 17d |  |  | 2PI1 | PI |
| 197 | 3.30.8 | Public Meeting/Public Hearings | 1d? | 2021-06-22 | 2021-06-22 | 195 | 16d | 0d | start no earlier than 2021-06-22 | 2PI1 | PI |
| 198 | 3.30.7 | Environmental Document Comments | 1d? | 2021-06-23 | 2021-06-23 | 197 | 16d |  |  | 2PI1 | PI |
| 199 | 3.31 | Assist with Public Engagement | 1d? | 2021-06-18 | 2021-06-18 | 192 | 19d |  |  | 2CG1 | CG |
| 200 | 3.32 | Various Outreach Materials | 1d? | 2021-06-21 | 2021-06-21 | 194 | 18d |  |  | 2CG1 | CG |
| 201 | 3.33 | Project Special Commitments (Green Sheets) (when applicable) | 1d? | 2021-07-01 | 2021-07-01 | 132 | 10d |  |  | 2CG1 | CG |
| 202 | 3.34 | **Complete CR-RAVE Studies/Reviews, CLEAR, and Conduct Value Assessment Activities** | 10d? | 2021-06-17 | 2021-06-30 |  | 7d |  |  | 2VM1 | VM |
| 203 | 3.34.1 | Constructability Review checklist | 1d? | 2021-06-17 | 2021-06-17 | 57 | 19d | 0d |  | 2VM1 | VM |
| 204 | 3.34.2 | Constructability Review Minutes/CR Log | 1d? | 2021-06-18 | 2021-06-18 | 203 | 19d |  |  | 2VM1 | VM |
| 205 | 3.34.3 | Risk Assessment Worksheet | 1d? | 2021-06-21 | 2021-06-21 | 66 | 5d | 0d |  | 2VM1 | VM |
| 206 | 3.34.4 | Risk Assessment Study | 1d? | 2021-06-22 | 2021-06-22 | 205 | 17d |  |  | 2VM1 | VM |
| 207 | 3.34.5 | Value Assessment | 1d? | 2021-06-22 | 2021-06-22 | 66, 205 | 5d | 0d |  | 2VM1 | VM |
| 208 | 3.34.6 | Value Assessment Worksheet | 1d? | 2021-06-23 | 2021-06-23 | 207 | 5d | 0d |  | 2VM1 | VM |
| 209 | 3.34.7 | Value Engineering (VE) Study Report | 1d? | 2021-06-24 | 2021-06-24 | 208 | 5d | 0d |  | 2VM1 | VM |
| 210 | 3.34.8 | Value Engineering (VE) Study Recommendations | 1d? | 2021-06-25 | 2021-06-25 | 209 | 5d | 0d |  | 2VM1 | VM |
| 211 | 3.34.9 | Final Dispositions (responses to recommendations) | 1d? | 2021-06-29 | 2021-06-29 | 210, 217 | 11d | 0d |  | 2VM1 | VM |
| 212 | 3.34.10 | CLEAR Database Search | 1d? | 2021-06-30 | 2021-06-30 | 211 | 11d |  |  | 2VM1 | VM |

| ID | WBS | Task | Type | Duration | Start | Finish | Predecessors | Total slack | Free slack | Task Code | Discipline Code | SAP MLSN |
| --- | --- | --- | --- | --- | --- | --- | --- | --- | --- | --- | --- | --- |
| 213 | 3.35 | **Prepare Initial Design Estimates** |  | 2d? | 2021-06-30 | 2021-07-01 |  | 10d |  | 2CS1 | CS |  |
| 214 | 3.35.1 | Construction Cost Estimate |  | 1d? | 2021-06-30 | 2021-06-30 | 218 | 10d | 0d | 2CS1 | CS |  |
| 215 | 3.35.2 | Cost Verification Letter |  | 1d? | 2021-07-01 | 2021-07-01 | 214 | 10d |  | 2CS1 | CS |  |
| 216 | 3.36 | **Prepare for Field Inspection** |  | 2d? | 2021-06-28 | 2021-06-29 |  | 5d |  | 2RD2 | RD |  |
| 217 | 3.36.1 | Field Inspection Plan Set |  | 1d? | 2021-06-28 | 2021-06-28 | 210 | 5d | 0d | 2RD2 | RD |  |
| 218 | 3.36.2 | Quantities for Construction Estimate |  | 1d? | 2021-06-29 | 2021-06-29 | 217 | 10d | 0d | 2RD2 | RD |  |
| 219 | 3.37 | Field Inspection & Environ. Document Complete | milestone | 0d | 2021-06-30 | 2021-06-30 | 217, 132 | 3d | 0d | MLSN | MLSN | M1006 & # based on Env Doc Type |
| 220 | 4 | **Plan-in-Hand (Stg 3)** |  | 3d? | 2021-06-30 | 2021-07-05 |  | 3d |  |  |  |  |
| 221 | 4.1 | Right of Way Plans Complete (RPC) | milestone | 0d | 2021-06-30 | 2021-06-30 | 219 | 11d |  | MLSN | MLSN | M0300 |
| 222 | 4.2 | **Complete Roadway Design** |  | 1d? | 2021-07-01 | 2021-07-01 | 219 | 4d | 1d | 3RD1 | RD |  |
| 223 | 4.2.1 | Right-of-Way Plan Set w/ Noise Wall Locations |  | 1d? | 2021-07-01 | 2021-07-01 |  | 4d |  | 3RD1 | RD |  |
| 224 | 4.2.2 | Quantities for Construction Estimate |  | 1d? | 2021-07-01 | 2021-07-01 |  | 4d |  | 3RD1 | RD |  |
| 225 | 4.2.3 | Roadway Design Plans Set for Permit Application |  | 1d? | 2021-07-01 | 2021-07-01 |  | 4d |  | 3RD1 | RD |  |
| 226 | 4.2.4 | Photometric Layout |  | 1d? | 2021-07-01 | 2021-07-01 |  | 4d |  | 3RD1 | RD |  |
| 227 | 4.2.5 | Lighting Plans Prepared in MicroStation |  | 1d? | 2021-07-01 | 2021-07-01 |  | 4d |  | 3RD1 | RD |  |
| 228 | 4.2.6 | Voltage Drop Calculations |  | 1d? | 2021-07-01 | 2021-07-01 |  | 4d |  | 3RD1 | RD |  |
| 229 | 4.2.7 | Typical Sections for Pavement Design Review |  | 1d? | 2021-07-01 | 2021-07-01 |  | 4d |  | 3RD1 | RD |  |
| 230 | 4.3 | **Verify Pavement Design** |  | 1d? | 2021-07-01 | 2021-07-01 | 219 | 4d | 1d | 3PD1 | PD |  |
| 231 | 4.3.1 | Final Pavement Design Verification Memo |  | 1d? | 2021-07-01 | 2021-07-01 |  | 4d |  | 3PD1 | PD |  |
| 232 | 4.3.2 | Typical section Review Email |  | 1d? | 2021-07-01 | 2021-07-01 |  | 4d |  | 3PD1 | PD |  |
| 233 | 4.3.3 | Shoulder Drain Memo |  | 1d? | 2021-07-01 | 2021-07-01 |  | 4d |  | 3PD1 | PD |  |
| 234 | 4.4 | **Complete Additional Surveys and Initiate ROW Acquisition Surveys** |  | 1d? | 2021-07-01 | 2021-07-01 | 219 | 4d | 1d | 3LS1 | LS |  |
| 235 | 4.4.1 | Additional Surveys |  | 1d? | 2021-07-01 | 2021-07-01 |  | 4d |  | 3LS1 | LS |  |
| 236 | 4.5 | **Complete Transportation Management Plan** |  | 1d? | 2021-07-01 | 2021-07-01 | 219 | 3d | 0d | 3TM1 | TM |  |
| 237 | 4.5.1 | Final Transportation Management Plan (TMP) Submittal |  | 1d? | 2021-07-01 | 2021-07-01 |  | 3d |  | 3TM1 | TM |  |

Notes:
- 219: SAP number for Field Inspection is M1006. The SAP number for the Env. Doc is dependent on the type of document.

| ID | WBS | Task | Type | Duration | Start | Finish | Predecessors | Total slack | Free slack | Task Code | Discipline Code | SAP MLSN |
| --- | --- | --- | --- | --- | --- | --- | --- | --- | --- | --- | --- | --- |
| 238 | 4.6 | **Advance Transportation Operations Plan (if a Significant Project)** |  | 1d? | 2021-07-01 | 2021-07-01 | 219 | 4d | 1d | 3TO1 | TO |  |
| 239 | 4.6.1 | Final Cost Estimate |  | 1d? | 2021-07-01 | 2021-07-01 |  | 4d |  | 3TO1 | TO |  |
| 240 | 4.6.2 | Requirements of Incident Management Plan |  | 1d? | 2021-07-01 | 2021-07-01 |  | 4d |  | 3TO1 | TO |  |
| 241 | 4.6.3 | Final Incident Management Alternate Detour Route Response Plan |  | 1d? | 2021-07-01 | 2021-07-01 |  | 4d |  | 3TO1 | TO |  |
| 242 | 4.6.4 | Final Demand Management Plan |  | 1d? | 2021-07-01 | 2021-07-01 |  | 4d |  | 3TO1 | TO |  |
| 243 | 4.6.5 | Draft Tow Contracts Documents |  | 1d? | 2021-07-01 | 2021-07-01 |  | 4d |  | 3TO1 | TO |  |
| 244 | 4.6.6 | Draft Law Enforcement Memorandum of Understanding |  | 1d? | 2021-07-01 | 2021-07-01 |  | 4d |  | 3TO1 | TO |  |
| 245 | 4.6.7 | Draft Agreement with Municipalities |  | 1d? | 2021-07-01 | 2021-07-01 |  | 4d |  | 3TO1 | TO |  |
| 246 | 4.6.8 | Coordination Meeting with NCDOT Communications |  | 1d? | 2021-07-01 | 2021-07-01 |  | 4d |  | 3TO1 | TO |  |
| 247 | 4.6.9 | Final Transportation Operations Plan |  | 1d? | 2021-07-01 | 2021-07-01 |  | 4d |  | 3TO1 | TO |  |
| 248 | 4.6.10 | Final Equipment List |  | 1d? | 2021-07-01 | 2021-07-01 |  | 4d |  | 3TO1 | TO |  |
| 249 | 4.7 | **Initiate Signal System Timing (if not a Significant Project)** |  | 1d? | 2021-07-02 | 2021-07-02 | 236 | 3d | 0d | 3SS1 | SS |  |
| 250 | 4.7.1 | Construction Signal Timing phases |  | 1d? | 2021-07-02 | 2021-07-02 |  | 3d |  | 3SS1 | SS |  |
| 251 | 4.7.2 | Summary of Existing Signal System Operations |  | 1d? | 2021-07-02 | 2021-07-02 |  | 3d |  | 3SS1 | SS |  |
| 252 | 4.7.3 | Existing Synchro and Tru-Traffic files |  | 1d? | 2021-07-02 | 2021-07-02 |  | 3d |  | 3SS1 | SS |  |
| 253 | 4.8 | **Complete Right-of-Way Consultation** |  | 1d? | 2021-07-01 | 2021-07-01 | 219 | 4d | 1d | 3EP1 | EP |  |
| 254 | 4.8.1 | NCDOT NEPA/SEPA Consultation Form |  | 1d? | 2021-07-01 | 2021-07-01 |  | 4d |  | 3EP1 | EP |  |
| 255 | 4.9 | **Prepare ROW Cost Estimate** |  | 1d? | 2021-07-01 | 2021-07-01 | 219 | 3d | 0d | 3RW1 | RW |  |
| 256 | 4.9.1 | ROW Cost Estimate (PH 200) |  | 1d? | 2021-07-01 | 2021-07-01 |  | 3d |  | 3RW1 | RW |  |
| 257 | 4.10 | **Complete ROW Authorization Package** |  | 1d? | 2021-07-02 | 2021-07-02 | 255 | 3d | 0d | 3RW2 | RW |  |
| 258 | 4.10.1 | ROW Authorization Letter |  | 1d? | 2021-07-02 | 2021-07-02 |  | 3d |  | 3RW2 | RW |  |
| 259 | 4.10.2 | ROW Cost Estimate |  | 1d? | 2021-07-02 | 2021-07-02 |  | 3d |  | 3RW2 | RW |  |
| 260 | 4.11 | Right of Way Acquisition Begins | milestone | 0d | 2021-07-02 | 2021-07-02 | 257 | 9d |  | MLSN | MLSN | M0302 |
| 261 | 4.12 | **Advance Utility Coordination** |  | 1d? | 2021-07-01 | 2021-07-01 | 219 | 4d | 1d | 3UT1 | UT |  |
| 262 | 4.12.1 | Utility Agreement Plans |  | 1d? | 2021-07-01 | 2021-07-01 |  | 4d |  | 3UT1 | UT |  |
| 263 | 4.12.2 | Utility Environmental Permit Plans and Narrative |  | 1d? | 2021-07-01 | 2021-07-01 |  | 4d |  | 3UT1 | UT |  |
| 264 | 4.12.3 | Cost Responsibility Analysis Report |  | 1d? | 2021-07-01 | 2021-07-01 |  | 4d |  | 3UT1 | UT |  |
| 265 | 4.12.4 | Final Utilities Coordination Working Plans |  | 1d? | 2021-07-01 | 2021-07-01 |  | 4d |  | 3UT1 | UT |  |

| ID | WBS | Task | Type | Duration | Start | Finish | Predecessors | Total slack | Free slack | Task Code | Discipline Code | SAP MLSN |
| --- | --- | --- | --- | --- | --- | --- | --- | --- | --- | --- | --- | --- |
| 266 | 4.13 | **Prepare Utility Relocation and Construction Estimates** |  | 1d? | 2021-07-01 | 2021-07-01 | 219 | 4d | 0d | 3UT2 | UT |  |
| 267 | 4.13.1 | Utility Relocation (PH 250) Estimate |  | 1d? | 2021-07-01 | 2021-07-01 |  | 4d |  | 3UT2 | UT |  |
| 268 | 4.13.2 | Utility Construction (PH 300) Estimate |  | 1d? | 2021-07-01 | 2021-07-01 |  | 4d |  | 3UT2 | UT |  |
| 269 | 4.14 | Utility Relocation by Others Begins | milestone | 0d | 2021-07-01 | 2021-07-01 | 266 | 10d |  | MLSN | MLSN | M0722 |
| 270 | 4.15 | **Prepare GeoEnvironmental Phase II Report** |  | 1d? | 2021-07-01 | 2021-07-01 | 219 | 4d | 1d | 3GT1 | GT |  |
| 271 | 4.15.1 | GeoEnvironmental Phase II Report |  | 1d? | 2021-07-01 | 2021-07-01 |  | 4d |  | 3GT1 | GT |  |
| 272 | 4.15.2 | GeoEnvironmental Right-of-Way Recommendations |  | 1d? | 2021-07-01 | 2021-07-01 |  | 4d |  | 3GT1 | GT |  |
| 273 | 4.15.3 | GeoEnvironmental Design and Environmental Conflict Memo |  | 1d? | 2021-07-01 | 2021-07-01 |  | 4d |  | 3GT1 | GT |  |
| 274 | 4.16 | **Conduct Subsurface Investigations & Provide Structures Recommendations** |  | 1d? | 2021-07-02 | 2021-07-02 | 75, 98 | 3d | 0d | 3GT2 | GT |  |
| 275 | 4.16.1 | Structure Subsurface Investigation Inventory Report with graphics |  | 1d? | 2021-07-02 | 2021-07-02 |  | 3d |  | 3GT2 | GT |  |
| 276 | 4.16.2 | Design Scour Report |  | 1d? | 2021-07-02 | 2021-07-02 |  | 3d |  | 3GT2 | GT |  |
| 277 | 4.16.3 | Inventory and Foundation Recommendation Report |  | 1d? | 2021-07-02 | 2021-07-02 |  | 3d |  | 3GT2 | GT |  |
| 278 | 4.16.4 | Structure Special Provisions |  | 1d? | 2021-07-02 | 2021-07-02 |  | 3d |  | 3GT2 | GT |  |
| 279 | 4.16.5 | Retaining Wall Subsurface Investigation Inventory Graphics |  | 1d? | 2021-07-02 | 2021-07-02 |  | 3d |  | 3GT2 | GT |  |
| 280 | 4.16.6 | Retaining Wall Recommendation Report with Details |  | 1d? | 2021-07-02 | 2021-07-02 |  | 3d |  | 3GT2 | GT |  |
| 281 | 4.16.7 | Retaining Wall Special Provisions |  | 1d? | 2021-07-02 | 2021-07-02 |  | 3d |  | 3GT2 | GT |  |
| 282 | 4.16.8 | Sound Barrier Subsurface Investigation Inventory Graphics |  | 1d? | 2021-07-02 | 2021-07-02 |  | 3d |  | 3GT2 | GT |  |
| 283 | 4.16.9 | Sound Barrier recommendations Report |  | 1d? | 2021-07-02 | 2021-07-02 |  | 3d |  | 3GT2 | GT |  |
| 284 | 4.16.10 | Temporary Shoring Recommendations |  | 1d? | 2021-07-02 | 2021-07-02 |  | 3d |  | 3GT2 | GT |  |
| 285 | 4.17 | **Complete Structures Design** |  | 1d? | 2021-07-01 | 2021-07-01 | 219 | 4d | 1d | 3ST1 | ST |  |
| 286 | 4.17.1 | Geotechnical Foundation Loads |  | 1d? | 2021-07-01 | 2021-07-01 |  | 4d |  | 3ST1 | ST |  |
| 287 | 4.17.2 | Access Drawings |  | 1d? | 2021-07-01 | 2021-07-01 |  | 4d |  | 3ST1 | ST |  |
| 288 | 4.17.3 | Permit Impacts |  | 1d? | 2021-07-01 | 2021-07-01 |  | 4d |  | 3ST1 | ST |  |
| 289 | 4.17.4 | Veritical Abutment Wall Envelopes |  | 1d? | 2021-07-01 | 2021-07-01 |  | 4d |  | 3ST1 | ST |  |
| 290 | 4.17.5 | Final Structure Plans Review |  | 1d? | 2021-07-01 | 2021-07-01 |  | 4d |  | 3ST1 | ST |  |

| ID | WBS | Task | Duration | Start | Finish | Predecessors | Total slack | Free slack | Task Code | Discipline Code |
| --- | --- | --- | --- | --- | --- | --- | --- | --- | --- | --- |
| 291 | 4.18 | **Complete Signal and ITS Design** | 1d? | 2021-07-01 | 2021-07-01 | 219 | 4d | 1d | 3SG1 | SG |
| 292 | 4.18.1 | Signal Plan and Electrical Detail Sheets | 1d? | 2021-07-01 | 2021-07-01 |  | 4d |  | 3SG1 | SG |
| 293 | 4.18.2 | Quantity and Cost Estimates | 1d? | 2021-07-01 | 2021-07-01 |  | 4d |  | 3SG1 | SG |
| 294 | 4.18.3 | Project Special Provisions | 1d? | 2021-07-01 | 2021-07-01 |  | 4d |  | 3SG1 | SG |
| 295 | 4.18.4 | Project Documentation | 1d? | 2021-07-01 | 2021-07-01 |  | 4d |  | 3SG1 | SG |
| 296 | 4.19 | **Complete Signing and Delineation Design** | 1d? | 2021-07-01 | 2021-07-01 | 219 | 4d | 1d | 3SD1 | SD |
| 297 | 4.19.1 | Approved Strip Map | 1d? | 2021-07-01 | 2021-07-01 |  | 4d |  | 3SD1 | SD |
| 298 | 4.19.2 | Overhead Sign Locations | 1d? | 2021-07-01 | 2021-07-01 |  | 4d |  | 3SD1 | SD |
| 299 | 4.19.3 | Three Way Check- QC/QA | 1d? | 2021-07-01 | 2021-07-01 |  | 4d |  | 3SD1 | SD |
| 300 | 4.19.4 | Final Plans | 1d? | 2021-07-01 | 2021-07-01 |  | 4d |  | 3SD1 | SD |
| 301 | 4.19.5 | Sign Designs and Support Chart | 1d? | 2021-07-01 | 2021-07-01 |  | 4d |  | 3SD1 | SD |
| 302 | 4.19.6 | Project Special Provisions | 1d? | 2021-07-01 | 2021-07-01 |  | 4d |  | 3SD1 | SD |
| 303 | 4.19.7 | Quantities | 1d? | 2021-07-01 | 2021-07-01 |  | 4d |  | 3SD1 | SD |
| 304 | 4.19.8 | Guardrail/Barrier Locations | 1d? | 2021-07-01 | 2021-07-01 |  | 4d |  | 3SD1 | SD |
| 305 | 4.20 | **Complete Hydraulic Design** | 1d? | 2021-07-01 | 2021-07-01 | 219 | 4d | 1d | 3HY1 | HY |
| 306 | 4.20.1 | Final Drainage Design | 1d? | 2021-07-01 | 2021-07-01 |  | 4d |  | 3HY1 | HY |
| 307 | 4.20.2 | FEMA Compliance Packages (MOA/CLOMR) | 1d? | 2021-07-01 | 2021-07-01 |  | 4d |  | 3HY1 | HY |
| 308 | 4.20.3 | Hydraulic Summary Sheet(s) | 1d? | 2021-07-01 | 2021-07-01 |  | 4d |  | 3HY1 | HY |
| 309 | 4.20.4 | Stormwater Management Plan | 1d? | 2021-07-01 | 2021-07-01 |  | 4d |  | 3HY1 | HY |
| 310 | 4.20.5 | Environmental Permit Drawings | 1d? | 2021-07-01 | 2021-07-01 |  | 4d |  | 3HY1 | HY |
| 311 | 4.20.6 | Merger CP4C Meeting Package and Minutes | 1d? | 2021-07-01 | 2021-07-01 |  | 4d |  | 3HY1 | HY |
| 312 | 4.21 | **Complete Railroad Design & Agreements** | 1d? | 2021-07-01 | 2021-07-01 | 219 | 4d | 1d | 3RR1 | RR |
| 313 | 4.21.1 | Railroad Signal Planimetric | 1d? | 2021-07-01 | 2021-07-01 |  | 4d |  | 3RR1 | RR |
| 314 | 4.21.2 | Railroad Crossing Signal Design | 1d? | 2021-07-01 | 2021-07-01 |  | 4d |  | 3RR1 | RR |
| 315 | 4.21.3 | Railroad Design Plans | 1d? | 2021-07-01 | 2021-07-01 |  | 4d |  | 3RR1 | RR |
| 316 | 4.21.4 | Relevant Railroad Agreements | 1d? | 2021-07-01 | 2021-07-01 |  | 4d |  | 3RR1 | RR |

| ID | WBS | Task | Type | Duration | Start | Finish | Predecessors | Total slack | Free slack | Task Code | Discipline Code | SAP MLSN |
| --- | --- | --- | --- | --- | --- | --- | --- | --- | --- | --- | --- | --- |
| 317 | 4.22 | **Complete Erosion and Sediment Control Plans** |  | 1d? | 2021-07-01 | 2021-07-01 | 219 | 4d | 1d | 3RE1 | RE |  |
| 318 | 4.22.1 | E&SC Plan Set |  | 1d? | 2021-07-01 | 2021-07-01 |  | 4d |  | 3RE1 | RE |  |
| 319 | 4.22.2 | E&SC Special Provisions & Quantities |  | 1d? | 2021-07-01 | 2021-07-01 |  | 4d |  | 3RE1 | RE |  |
| 320 | 4.22.3 | Approved Applicable Permits/Variances |  | 1d? | 2021-07-01 | 2021-07-01 |  | 4d |  | 3RE1 | RE |  |
| 321 | 4.23 | **Complete Permit, Commitments, and Design Noise Report or Addendum** |  | 1d? | 2021-07-01 | 2021-07-01 | 219 | 4d | 0d | 3EN1 | EN |  |
| 322 | 4.23.1 | Permit Applications |  | 1d? | 2021-07-01 | 2021-07-01 |  | 4d |  | 3EN1 | EN |  |
| 323 | 4.23.2 | Design Noise Report or Design Noise Report Addendum, as applicable |  | 1d? | 2021-07-01 | 2021-07-01 |  | 4d |  | 3EN1 | EN |  |
| 324 | 4.24 | **Determine Final Noise Abatement** |  | 1d? | 2021-07-02 | 2021-07-02 | 321 | 9d |  | 3EN2 | EN |  |
| 325 | 4.24.1 | Benefited Receptor Mailing List |  | 1d? | 2021-07-02 | 2021-07-02 |  | 9d |  | 3EN2 | EN |  |
| 326 | 4.24.2 | Notice of Upcoming Ballot and/or Public Noise Meeting (optional) |  | 1d? | 2021-07-02 | 2021-07-02 |  | 9d |  | 3EN2 | EN |  |
| 327 | 4.24.3 | Noise Ballots |  | 1d? | 2021-07-02 | 2021-07-02 |  | 9d |  | 3EN2 | EN |  |
| 328 | 4.24.4 | Noise Wall Balloting Results |  | 1d? | 2021-07-02 | 2021-07-02 |  | 9d |  | 3EN2 | EN |  |
| 329 | 4.25 | **Incorporate CR-RAVE Outcomes, Submit CLEAR, and Implement Value Assessment Activities** |  | 1d? | 2021-07-01 | 2021-07-01 | 219 | 4d | 1d | 3VM1 | VM |  |
| 330 | 4.25.1 | Constructability Review Checklist |  | 1d? | 2021-07-01 | 2021-07-01 |  | 4d |  | 3VM1 | VM |  |
| 331 | 4.25.2 | Constructability Review Minutes/ CR Log |  | 1d? | 2021-07-01 | 2021-07-01 |  | 4d |  | 3VM1 | VM |  |
| 332 | 4.25.3 | Risk Assessment Worksheet |  | 1d? | 2021-07-01 | 2021-07-01 |  | 4d |  | 3VM1 | VM |  |
| 333 | 4.25.4 | Risk Assessment Study Report |  | 1d? | 2021-07-01 | 2021-07-01 |  | 4d |  | 3VM1 | VM |  |
| 334 | 4.25.5 | Value Assessment Recommendations |  | 1d? | 2021-07-01 | 2021-07-01 |  | 4d |  | 3VM1 | VM |  |
| 335 | 4.25.6 | Value Engineering Study Report (including VE recommendation Forms) |  | 1d? | 2021-07-01 | 2021-07-01 |  | 4d |  | 3VM1 | VM |  |
| 336 | 4.25.7 | CLEAR Database Submission |  | 1d? | 2021-07-01 | 2021-07-01 |  | 4d |  | 3VM1 | VM |  |
| 337 | 4.26 | **Prepare Plan-in-Hand Estimates** |  | 1d? | 2021-07-05 | 2021-07-05 | 234, 238, 249, 257, 261, 230, 285, 274, 291, 222, 296, 305, 312, 317, 321, 270, 253, 255, 266, 329 | 3d | 0d | 3CS1 | CS |  |
| 338 | 4.26.1 | Construction Cost Estimate |  | 1d? | 2021-07-05 | 2021-07-05 |  | 3d |  | 3CS1 | CS |  |
| 339 | 4.26.2 | Cost Verification Letter |  | 1d? | 2021-07-05 | 2021-07-05 |  | 3d |  | 3CS1 | CS |  |
| 340 | 4.27 | Design Complete & All Permit Applications Submitted | milestone | 0d | 2021-07-05 | 2021-07-05 | 337 | 3d | 0d | MLSN | MLSN | M1007 |

| ID | WBS | Task | Type | Duration | Start | Finish | Predecessors | Total slack | Free slack | Task Code | Discipline Code | SAP MLSN |
| --- | --- | --- | --- | --- | --- | --- | --- | --- | --- | --- | --- | --- |
| 341 | 5 | **Plans, Specifications, and Estimates (Stage 4)** |  | 21d? | 2021-06-14 | 2021-07-12 | 3 | 3d |  |  |  |  |
| 342 | 5.1 | **Complete ROW Acquisitions and Relocations** |  | 17d? | 2021-06-14 | 2021-07-06 |  | 7d |  | 4RW1 | RW |  |
| 343 | 5.1.1 | Request ROW Certification |  | 1d? | 2021-07-06 | 2021-07-06 | 340 | 3d | 0d | 4RW1 | RW |  |
| 344 | 5.1.2 | Negotiations |  | 1d? | 2021-06-14 | 2021-06-14 |  | 23d |  | 4RW1 | RW |  |
| 345 | 5.1.3 | Condemnation |  | 1d? | 2021-06-14 | 2021-06-14 |  | 23d |  | 4RW1 | RW |  |
| 346 | 5.1.4 | Relocations |  | 1d? | 2021-06-14 | 2021-06-14 |  | 23d |  | 4RW1 | RW |  |
| 347 | 5.2 | Right of Way Parcels Accessible | milestone | 0d | 2021-07-06 | 2021-07-06 | 343 | 7d |  | MLSN | MLSN | M0726 |
| 348 | 5.3 | **Prepare GeoEnvironmental Phase III Reports** |  | 1d? | 2021-07-06 | 2021-07-06 | 340 | 3d | 0d | 4GT1 | GT |  |
| 349 | 5.3.1 | Underground Storage Tank Closure Report |  | 1d? | 2021-07-06 | 2021-07-06 |  | 3d |  | 4GT1 | GT |  |
| 350 | 5.3.2 | Environmental Groundwater Monitoring Well and Closure Report |  | 1d? | 2021-07-06 | 2021-07-06 |  | 3d |  | 4GT1 | GT |  |
| 351 | 5.3.3 | Contaminated Soil Removal Report |  | 1d? | 2021-07-06 | 2021-07-06 |  | 3d |  | 4GT1 | GT |  |
| 352 | 5.3.4 | Contaminated Materials Management Plan |  | 1d? | 2021-07-06 | 2021-07-06 |  | 3d |  | 4GT1 | GT |  |
| 353 | 5.4 | **Finalize Structures Design PS&E** |  | 1d? | 2021-07-06 | 2021-07-06 | 340 | 3d | 0d | 4ST1 | ST |  |
| 354 | 5.4.1 | Structures Final Plans |  | 1d? | 2021-07-06 | 2021-07-06 |  | 3d |  | 4ST1 | ST |  |
| 355 | 5.4.2 | Structures Working Days |  | 1d? | 2021-07-06 | 2021-07-06 |  | 3d |  | 4ST1 | ST |  |
| 356 | 5.4.3 | Structures Project Special Provisions |  | 1d? | 2021-07-06 | 2021-07-06 |  | 3d |  | 4ST1 | ST |  |
| 357 | 5.4.4 | Structures Quantity Estimate (CSV) |  | 1d? | 2021-07-06 | 2021-07-06 |  | 3d |  | 4ST1 | ST |  |
| 358 | 5.4.5 | Structure Design Files |  | 1d? | 2021-07-06 | 2021-07-06 |  | 3d |  | 4ST1 | ST |  |
| 359 | 5.4.6 | Bridge Construction Elevations |  | 1d? | 2021-07-06 | 2021-07-06 |  | 3d |  | 4ST1 | ST |  |
| 360 | 5.4.7 | Roadway Structures Checklist |  | 1d? | 2021-07-06 | 2021-07-06 |  | 3d |  | 4ST1 | ST |  |
| 361 | 5.4.8 | Wall Plans |  | 1d? | 2021-07-06 | 2021-07-06 |  | 3d |  | 4ST1 | ST |  |
| 362 | 5.4.9 | Final Plans |  | 1d? | 2021-07-06 | 2021-07-06 |  | 3d |  | 4ST1 | ST |  |
| 363 | 5.5 | **Complete ROW Acquisition Surveys** |  | 1d? | 2021-07-06 | 2021-07-06 | 340 | 3d | 0d | 4LS1 | LS |  |
| 364 | 5.5.1 | ROW Field Delineation |  | 1d? | 2021-07-06 | 2021-07-06 |  | 3d |  | 4LS1 | LS |  |
| 365 | 5.5.2 | ROW Metes and Bounds Descriptions |  | 1d? | 2021-07-06 | 2021-07-06 |  | 3d |  | 4LS1 | LS |  |
| 366 | 5.5.3 | Eminent Domain Exhibit Maps |  | 1d? | 2021-07-06 | 2021-07-06 |  | 3d |  | 4LS1 | LS |  |
| 367 | 5.5.4 | ROW Reference File |  | 1d? | 2021-07-06 | 2021-07-06 |  | 3d |  | 4LS1 | LS |  |
| 368 | 5.5.5 | Final ROW Series Plan Set |  | 1d? | 2021-07-06 | 2021-07-06 |  | 3d |  | 4LS1 | LS |  |

| ID | WBS | Task | Type | Duration | Start | Finish | Predecessors | Total slack | Free slack | Task Code | Discipline Code | SAP MLSN |
| --- | --- | --- | --- | --- | --- | --- | --- | --- | --- | --- | --- | --- |
| 369 | 5.6 | **Complete Any Open Hydraulic Tasks** |  | 1d? | 2021-07-06 | 2021-07-06 | 340 | 3d | 0d | 4HY1 | HY |  |
| 370 | 5.6.1 | All outstanding deliverables including QC Checklists |  | 1d? | 2021-07-06 | 2021-07-06 |  | 3d |  | 4HY1 | HY |  |
| 371 | 5.7 | **Finalize Erosion and Sediment Control Contract Package** |  | 1d? | 2021-07-06 | 2021-07-06 | 340 | 3d | 0d | 4RE1 | RE |  |
| 372 | 5.7.1 | Approved E&SC Contract Package |  | 1d? | 2021-07-06 | 2021-07-06 |  | 3d |  | 4RE1 | RE |  |
| 373 | 5.7.2 | Approved Applicable Permits/Variances |  | 1d? | 2021-07-06 | 2021-07-06 |  | 3d |  | 4RE1 | RE |  |
| 374 | 5.8 | **Complete Construction Consultation** |  | 1d? | 2021-07-06 | 2021-07-06 | 340 | 3d | 0d | 4EP1 | EP |  |
| 375 | 5.8.1 | NCDOT NEPA/SEPA Consultation Form |  | 1d? | 2021-07-06 | 2021-07-06 |  | 3d |  | 4EP1 | EP |  |
| 376 | 5.9 | **Complete Utility Coordination** |  | 1d? | 2021-07-06 | 2021-07-06 | 340 | 3d | 0d | 4UT1 | UT |  |
| 377 | 5.9.1 | Utilities by Others Plans and Special Provisions |  | 1d? | 2021-07-06 | 2021-07-06 |  | 3d |  | 4UT1 | UT |  |
| 378 | 5.9.2 | Utility Construction Plans (PS&E) |  | 1d? | 2021-07-06 | 2021-07-06 |  | 3d |  | 4UT1 | UT |  |
| 379 | 5.9.3 | Water and Sewer Permits |  | 1d? | 2021-07-06 | 2021-07-06 |  | 3d |  | 4UT1 | UT |  |
| 380 | 5.9.4 | Executed Utility Agreements |  | 1d? | 2021-07-06 | 2021-07-06 |  | 3d |  | 4UT1 | UT |  |
| 381 | 5.9.5 | Utility Authorizations |  | 1d? | 2021-07-06 | 2021-07-06 |  | 3d |  | 4UT1 | UT |  |
| 382 | 5.9.6 | Utility Certifications |  | 1d? | 2021-07-06 | 2021-07-06 |  | 3d |  | 4UT1 | UT |  |
| 383 | 5.10 | **Complete Utility Relocation by Owner** |  | 1d? | 2021-07-06 | 2021-07-06 | 340 | 3d | 0d | 4UT2 | UT |  |
| 384 | 5.10.1 | Relocation Scheduling Conference |  | 1d? | 2021-07-06 | 2021-07-06 |  | 3d |  | 4UT2 | UT |  |
| 385 | 5.10.2 | Updated Utilities Relocation Schedule |  | 1d? | 2021-07-06 | 2021-07-06 |  | 3d |  | 4UT2 | UT |  |
| 386 | 5.11 | **Prepare Final Utility Construction Estimates** |  | 1d? | 2021-07-06 | 2021-07-06 | 340 | 3d | 0d | 4UT3 | UT |  |
| 387 | 5.11.1 | Final Utility Construction (PH 300) Estimate |  | 1d? | 2021-07-06 | 2021-07-06 |  | 3d |  | 4UT3 | UT |  |
| 388 | 5.12 | Utility Relocation by Others Complete | milestone | 0d | 2021-07-06 | 2021-07-06 | 386 | 7d |  | MLSN | MLSN | M0724 |
| 389 | 5.13 | **Complete Transportation Operations Plan-Related Tasks (if a Significant Project)** |  | 1d? | 2021-07-06 | 2021-07-06 | 340 | 3d | 0d | 4TO1 | TO |  |
| 390 | 5.13.1 | Final Tow Contract Documents |  | 1d? | 2021-07-06 | 2021-07-06 |  | 3d |  | 4TO1 | TO |  |
| 391 | 5.13.2 | Final Law Enforcement Memorandum of Understanding (MOUs) |  | 1d? | 2021-07-06 | 2021-07-06 |  | 3d |  | 4TO1 | TO |  |
| 392 | 5.13.3 | STOC Operators Training |  | 1d? | 2021-07-06 | 2021-07-06 |  | 3d |  | 4TO1 | TO |  |
| 393 | 5.13.4 | IMAP Procurement Schedule |  | 1d? | 2021-07-06 | 2021-07-06 |  | 3d |  | 4TO1 | TO |  |

| ID | WBS | Task | Type | Duration | Start | Finish | Predecessors | Total slack | Free slack | Task Code | Discipline Code | SAP MLSN |
| --- | --- | --- | --- | --- | --- | --- | --- | --- | --- | --- | --- | --- |
| 394 | 5.14 | **Complete CR-RAVE, CLEAR, and Value Assessment Activities** |  | 1d? | 2021-07-06 | 2021-07-06 | 340 | 3d | 0d | 4VM1 | VM |  |
| 395 | 5.14.1 | Constructability Review Minutes/CR Log |  | 1d? | 2021-07-06 | 2021-07-06 |  | 3d |  | 4VM1 | VM |  |
| 396 | 5.14.2 | Risk Assessment worksheet |  | 1d? | 2021-07-06 | 2021-07-06 |  | 3d |  | 4VM1 | VM |  |
| 397 | 5.14.3 | Value Assessment |  | 1d? | 2021-07-06 | 2021-07-06 |  | 3d |  | 4VM1 | VM |  |
| 398 | 5.14.4 | Value Engineering (VE) Study report |  | 1d? | 2021-07-06 | 2021-07-06 |  | 3d |  | 4VM1 | VM |  |
| 399 | 5.14.5 | CLEAR Database Submissions |  | 1d? | 2021-07-06 | 2021-07-06 |  | 3d |  | 4VM1 | VM |  |
| 400 | 5.15 | **Secure Environmental Permits** |  | 1d? | 2021-07-06 | 2021-07-06 | 340 | 3d | 0d | 4EN1 | EN |  |
| 401 | 5.15.1 | Permit Package |  | 1d? | 2021-07-06 | 2021-07-06 |  | 3d |  | 4EN1 | EN |  |
| 402 | 5.15.2 | Project Special Commitments (Green Sheets) |  | 1d? | 2021-07-06 | 2021-07-06 |  | 3d |  | 4EN1 | EN |  |
| 403 | 5.16 | **Complete Railroad Coordination** |  | 1d? | 2021-07-06 | 2021-07-06 | 340 | 3d | 0d | 4RR1 | RR |  |
| 404 | 5.16.1 | Railroad Agreements |  | 1d? | 2021-07-06 | 2021-07-06 |  | 3d |  | 4RR1 | RR |  |
| 405 | 5.16.2 | Project Special Provisions |  | 1d? | 2021-07-06 | 2021-07-06 |  | 3d |  | 4RR1 | RR |  |
| 406 | 5.17 | **Prepare Construction Communication Activities** |  | 1d? | 2021-07-06 | 2021-07-06 | 340 | 3d | 0d | 4CG1 | CG |  |
| 407 | 5.17.1 | Construction Outreach Material (varies by need) |  | 1d? | 2021-07-06 | 2021-07-06 |  | 3d |  | 4CG1 | CG |  |
| 408 | 5.17.2 | Construction Public Information Plan |  | 1d? | 2021-07-06 | 2021-07-06 |  | 3d |  | 4CG1 | CG |  |
| 409 | 5.18 | Request Construction Funds |  | 1d? | 2021-07-06 | 2021-07-06 | 340 | 3d | 0d |  | PM |  |
| 410 | 5.19 | **Finalize the Final PS&E Package** |  | 1d? | 2021-07-07 | 2021-07-07 | 348, 353, 363, 369, 383, 389, 400, 403, 406, 376, 371, 374, 386, 394, 343, 409 | 3d | 0d | 4RD1 | RD |  |
| 411 | 5.19.1 | Review Set of Final Plans |  | 1d? | 2021-07-07 | 2021-07-07 |  | 3d |  | 4RD1 | RD |  |
| 412 | 5.19.2 | Final Construction Quantities for Roadway Design Plans |  | 1d? | 2021-07-07 | 2021-07-07 |  | 3d |  | 4RD1 | RD |  |
| 413 | 5.19.3 | Sealed Contract Roadway Design Plans |  | 1d? | 2021-07-07 | 2021-07-07 |  | 3d |  | 4RD1 | RD |  |
| 414 | 5.20 | **Complete PS&E Package and Advertise the Project** |  | 1d? | 2021-07-08 | 2021-07-08 | 410 | 3d | 0d | 4CS1 | CS |  |
| 415 | 5.20.1 | Final Plans |  | 1d? | 2021-07-08 | 2021-07-08 |  | 3d |  | 4CS1 | CS |  |
| 416 | 5.20.2 | Proposal |  | 1d? | 2021-07-08 | 2021-07-08 |  | 3d |  | 4CS1 | CS |  |
| 417 | 5.20.3 | Confidential Engineer's Estimate |  | 1d? | 2021-07-08 | 2021-07-08 |  | 3d |  | 4CS1 | CS |  |
| 418 | 5.21 | Let Project | milestone | 0d | 2021-07-08 | 2021-07-08 | 414 | 3d | 0d | MLSN | MLSN | M1008 |

| ID | WBS | Task | Duration | Start | Finish | Predecessors | Total slack | Free slack | Task Code | Discipline Code |
| --- | --- | --- | --- | --- | --- | --- | --- | --- | --- | --- |
| 419 | 5.22 | **Let, Award and Execute** | 1d? | 2021-07-09 | 2021-07-09 | 418 | 3d | 0d | 4CS2 | CS |
| 420 | 5.22.1 | Award Letter | 1d? | 2021-07-09 | 2021-07-09 |  | 3d |  | 4CS2 | CS |
| 421 | 5.22.2 | Goal Confirmation Letter | 1d? | 2021-07-09 | 2021-07-09 |  | 3d |  | 4CS2 | CS |
| 422 | 5.22.3 | Execution Letter | 1d? | 2021-07-09 | 2021-07-09 |  | 3d |  | 4CS2 | CS |
| 423 | 5.23 | Post-Letting Activities | 1d? | 2021-07-12 | 2021-07-12 | 419 | 3d |  |  |  |
